# RateApplication

Schedule from MS Project, 2025-07-14 to 2026-08-07, costs in $.

## Calendars

- Standard: Mon-Fri 08:00-12:00, 13:00-17:00; Sat-Sun off.

## Resources

| Resource | Rate |
| --- | --- |
| Jeff | 48.08 |
| Eric | 48.08 |
| Sally | 57.69 |
| Bob | 38.46 |
| Ned | 45.67 |
| Software |  |
| Hardware | 1 |
| Travel |  |

## Schedule

| ID | Task | Type | Duration | Start | Finish | Predecessors | Total slack | Free slack | Resources | Work | Cost |
| --- | --- | --- | --- | --- | --- | --- | --- | --- | --- | --- | --- |
| 1 | Define Requirements |  | 20d | 2025-07-14 | 2025-08-08 |  | 0d |  | Eric | 160h | 12,793.85 |
| 2 | Review Existing Systems |  | 30d | 2025-08-11 | 2025-09-19 | 1 | 0d |  | Jeff | 240h | 19,190.77 |
| 3 | Finalize System Design |  | 40d | 2025-09-22 | 2025-11-14 | 2 | 0d |  | Eric; Jeff | 640h | 51,175.38 |
| 4 | Identify Needed Hardware |  | 20d | 2025-11-17 | 2025-12-12 | 3 | 0d |  | Ned | 160h | 12,154.15 |
| 5 | Identify Needed Software |  | 20d | 2025-11-17 | 2025-12-12 | 3 | 165d | 0d | Bob; Ned | 320h | 22,389.23 |
| 6 | Purchase Hardware |  | 5d | 2025-12-15 | 2025-12-19 | 4 | 165d |  | Hardware |  | 117,600 |
| 7 | Purchase Software Licenses |  | 5d | 2025-12-15 | 2025-12-19 | 5 | 165d |  | Software [500000%] |  | 5,880 |
| 8 | Receive Hardware |  | 30d | 2025-12-15 | 2026-01-23 | 4 | 0d |  | Jeff | 240h | 19,462.64 |
| 9 | Install Hardware |  | 20d | 2026-01-26 | 2026-02-20 | 8 | 0d |  | Sally | 160h | 15,736.43 |
| 10 | Install Software |  | 20d | 2026-02-23 | 2026-03-20 | 9 | 0d |  | Bob | 160h | 10,490.95 |
| 11 | Configure System |  | 30d | 2026-03-23 | 2026-05-01 | 10 | 0d |  | Eric; Ned | 480h | 38,357.55 |
| 12 | Internal Testing |  | 30d | 2026-05-04 | 2026-06-12 | 11 | 0d |  | Sally; Ned; Travel [250000%] | 480h | 45,091.66 |
| 13 | Resolve Issues |  | 20d | 2026-06-15 | 2026-07-10 | 12 | 0d |  | Ned; Sally | 320h | 28,194.44 |
| 14 | Final User Testing |  | 20d | 2026-07-13 | 2026-08-07 | 13 | 0d |  | Jeff | 160h | 13,113.69 |
| 15 | Go Live | milestone | 0d | 2026-08-07 | 2026-08-07 | 14 | 0d |  |  |  |  |
